# TGI Management

Schedule from MS Project, 2011-03-14 to 2011-05-04, A marks actual dates.
PARC

## Calendars

- Standard: Mon-Thu 08:00-12:00, 13:00-17:00; Fri-Sat off; Sun 09:00-18:00. Exceptions (off unless hours are given): 2011-03-20 08:00-12:00, 13:00-17:00, 2011-04-03 08:00-12:00, 13:00-17:00.

## Resources

| Resource |
| --- |
| Allwyn |
| Jayant |
| jay |
| Ali |

## Schedule

| ID | WBS | Task | Duration | Start | Finish | Predecessors | Complete | Remaining | Total slack | Free slack | Constraint | Resources | Work | Actual work |
| --- | --- | --- | --- | --- | --- | --- | --- | --- | --- | --- | --- | --- | --- | --- |
| 1 | 1 | **TGI Management** | 38.5d? | 2011-03-14 09:00 A | 2011-05-04 18:00 |  | 65% | 13.55d? | 0d |  |  |  | 319.04h | 197.04h |
| 2 | 1.1 | Requirement Analysis | 0.88d? | 2011-03-14 09:00 A | 2011-03-14 18:00 A |  | 100% |  |  |  | finish no earlier than 2011-03-14 18:00 | Allwyn | 7h | 7h |
| 3 | 1.2 | Design and Specification | 1.88d? | 2011-03-15 09:00 A | 2011-03-16 18:00 A |  | 100% |  |  |  | finish no earlier than 2011-03-16 18:00 | Jayant | 15h | 15h |
| 4 | 1.3 | Get Approval for Design | 8d? | 2011-03-17 09:00 A | 2011-03-28 18:00 A | 3 | 100% |  |  |  | finish no earlier than 2011-03-28 18:00 | Allwyn | 64h | 64h |
| 5 | 1.4 | Database Design | 1.38d? | 2011-03-28 13:57 A | 2011-03-29 18:00 A |  | 100% |  |  |  | finish no earlier than 2011-03-29 18:00 | Jayant | 11.04h | 11.04h |
| 6 | 1.5 | **Coding Application** | 18.25d? | 2011-03-30 09:00 A | 2011-04-24 18:00 |  | 69% | 5.58d? | 8.12d |  |  |  | 144h | 100h |
| 7 | 1.5.1 | Creating Framework | 0.88d? | 2011-03-30 09:00 A | 2011-03-30 18:00 A |  | 100% |  |  |  | finish no earlier than 2011-03-30 18:00 | Jayant | 7h | 7h |
| 8 | 1.5.2 | Data Manipulating Class | 1.88d? | 2011-03-31 09:00 | 2011-04-03 18:00 |  |  |  | 23.5d |  | finish no earlier than 2011-04-03 18:00 | Jayant | 15h |  |
| 9 | 1.5.3 | User Maintenance Form#1 | 0.88d? | 2011-04-04 09:00 A | 2011-04-04 18:00 A |  | 100% |  |  |  | finish no earlier than 2011-04-04 18:00 | Jayant | 7h | 7h |
| 10 | 1.5.4 | **PO Entering Form#2 - Accounts** | 11.12d? | 2011-04-05 09:00 A | 2011-04-19 18:00 A |  | 100% |  |  |  |  |  | 86h | 86h |
| 11 | 1.5.4.1 | Master Maintenance Forms | 5d | 2011-04-05 09:00 A | 2011-04-11 18:00 A |  | 100% |  |  |  | finish no earlier than 2011-04-11 18:00 | Jayant | 40h | 40h |
| 12 | 1.5.4.2 | PO Data Entry | 2.88d? | 2011-04-12 09:00 A | 2011-04-14 18:00 A | 11 | 100% |  |  |  | finish no earlier than 2011-04-14 18:00 | Jayant | 23h | 23h |
| 13 | 1.5.4.3 | Execution Data Entry Forms | 2.88d? | 2011-04-17 11:00 A | 2011-04-19 18:00 A | 12 | 100% |  |  |  | finish no earlier than 2011-04-19 18:00 | Jayant | 23h | 23h |
| 14 | 1.5.5 | **Report** | 3d? | 2011-04-20 09:00 | 2011-04-24 18:00 |  |  |  | 8.12d |  |  |  | 29h |  |
| 15 | 1.5.5.1 | Report # 1 | 1.88d? | 2011-04-20 09:00 | 2011-04-21 18:00 |  |  |  | 9.25d |  | finish no earlier than 2011-04-21 18:00 | Jayant | 15h |  |
| 16 | 1.5.5.2 | Report # 2 | 0.88d? | 2011-04-21 09:00 | 2011-04-21 18:00 |  |  |  | 8.38d | 0.25d | finish no earlier than 2011-04-21 18:00 | Jayant | 7h |  |
| 17 | 1.5.5.3 | Report # 3 | 0.88d? | 2011-04-24 11:00 | 2011-04-24 18:00 | 16 |  |  | 8.12d |  | finish no earlier than 2011-04-24 18:00 | Jayant | 7h |  |
| 18 | 1.6 | Testing | 1.88d? | 2011-04-25 09:00 | 2011-04-26 18:00 |  |  |  | 6.12d |  | finish no earlier than 2011-04-26 18:00 | Allwyn; Ali | 30h |  |
| 19 | 1.7 | Maintaining | 6d? | 2011-04-27 09:00 | 2011-05-04 18:00 |  |  |  | 0d |  | finish no earlier than 2011-05-04 18:00 | Jayant | 48h |  |
